# 1143_06_1_F_nyers

Schedule from MS Project, 2010-10-18 to 2010-12-21, costs in Ft, A marks actual dates.

## Calendars

- Szabványos: Mon-Fri 08:00-12:00, 13:00-17:00; Sat-Sun off.

## Resources

| Resource | Rate |
| --- | --- |
| okt menedzser | 2000 |
| okt vezető | 2000 |
| oktszerv | 1500 |
| szakértő | 3000 |
| tartalomfejlesztő | 2500 |

## Schedule

| ID | WBS | Task | Type | Duration | Start | Finish | Predecessors | Complete | Remaining | Total slack | Constraint | Resources | Work | Actual work | Cost | Actual cost |
| --- | --- | --- | --- | --- | --- | --- | --- | --- | --- | --- | --- | --- | --- | --- | --- | --- |
| 1 | 1 | **Belső felkészítés** |  | 46.5d | 2010-10-18 A | 2010-12-21 |  | 11% | 41.39d | 0d |  |  | 296h | 24h | 548,000 | 48,000 |
| 2 | 1.1 | **A belső értékesítési felkészítő csapat összeállítása** |  | 4d | 2010-10-18 A | 2010-10-21 A |  | 100% |  |  |  |  | 24h | 24h | 48,000 | 48,000 |
| 3 | 1.1.1 | Csapatvezető kijelölése |  | 1d | 2010-10-18 A | 2010-10-18 A |  | 100% |  |  |  | okt menedzser | 8h | 8h | 16,000 | 16,000 |
| 4 | 1.1.2 | Erőforrások kijelölése a következő csoportokból |  | 2d | 2010-10-18 A | 2010-10-19 A |  | 100% |  |  |  |  |  |  |  |  |
| 5 | 1.1.3 | Szerepek és felelősségek meghatározása |  | 2d | 2010-10-20 A | 2010-10-21 A | 3, 4 | 100% |  |  |  | okt vezető | 16h | 16h | 32,000 | 32,000 |
| 6 | 1.1.4 | belső értékesítési csapat kész | milestone | 0d | 2010-10-21 A | 2010-10-21 A | 5 | 100% |  |  |  |  |  |  |  |  |
| 7 | 1.2 | **Igények felmérése** |  | 20.5d | 2010-10-26 | 2010-11-23 |  |  |  | 0d |  |  | 112h |  | 180,000 |  |
| 8 | 1.2.1 | Értékesítési képzési projekt indítása – projektindító értekezlet |  | 4h | 2010-10-26 | 2010-10-26 | 6SS+2d |  |  | 0d |  | okt vezető; oktszerv; szakértő; tartalomfejlesztő | 16h |  | 36,000 |  |
| 9 | 1.2.2 | Képzési igények és kulcsfontosságú erőforrások áttekintése |  | 8d | 2010-10-26 | 2010-11-05 | 8 |  |  | 0d |  |  |  |  |  |  |
| 10 | 1.2.3 | **Képzési tartalom áttekintése** |  | 6d | 2010-11-05 | 2010-11-15 |  |  |  | 0d |  |  | 48h |  | 72,000 |  |
| 11 | 1.2.3.1 | Az aktuális képzési anyagok hiányosságainak feltérképezése |  | 2d | 2010-11-05 | 2010-11-09 | 9 |  |  | 0d |  | oktszerv | 16h |  | 24,000 |  |
| 12 | 1.2.3.2 | A képzési anyagokról készült tartalomfejlesztői visszajelzések áttekintése |  | 1d | 2010-11-09 | 2010-11-10 | 11 |  |  | 0d |  | oktszerv | 8h |  | 12,000 |  |
| 13 | 1.2.3.3 | Az aktuális képzési anyagok újrafelhasználható összetevőinek azonosítása |  | 2d | 2010-11-10 | 2010-11-12 | 12 |  |  | 0d |  | oktszerv | 16h |  | 24,000 |  |
| 14 | 1.2.3.4 | Eredmények dokumentálása |  | 1d | 2010-11-12 | 2010-11-15 | 13 |  |  | 0d |  | oktszerv | 8h |  | 12,000 |  |
| 15 | 1.2.3.5 | képzési anyagok áttekintése kész | milestone | 0d | 2010-11-15 | 2010-11-15 | 14 |  |  | 0d |  |  |  |  |  |  |
| 16 | 1.2.4 | **Képzési program áttekintése** |  | 6d | 2010-11-15 | 2010-11-23 |  |  |  | 0d |  |  | 48h |  | 72,000 |  |
| 17 | 1.2.4.1 | Az aktuális képzési módszerek katalogizálása |  | 1d | 2010-11-15 | 2010-11-16 | 15 |  |  | 0d |  | oktszerv | 8h |  | 12,000 |  |
| 18 | 1.2.4.2 | A leghatékonyabbnak bizonyult módszerek meghatározása |  | 1d | 2010-11-16 | 2010-11-17 | 17 |  |  | 0d |  | oktszerv | 8h |  | 12,000 |  |
| 19 | 1.2.4.3 | A korábban bevezetett képzési programok során felmerült problémák áttekintése |  | 2d | 2010-11-17 | 2010-11-19 | 18 |  |  | 0d |  | oktszerv | 16h |  | 24,000 |  |
| 20 | 1.2.4.4 | Az oktatók képzési programokról adott visszajelzéseinek áttekintése |  | 1d | 2010-11-19 | 2010-11-22 | 19 |  |  | 0d |  | oktszerv | 8h |  | 12,000 |  |
| 21 | 1.2.4.5 | Eredmények dokumentálása |  | 1d | 2010-11-22 | 2010-11-23 | 20 |  |  | 0d | as late as possible | oktszerv | 8h |  | 12,000 |  |
| 22 | 1.2.4.6 | képzési program áttekintése kész | milestone | 0d | 2010-11-23 | 2010-11-23 | 21 |  |  | 0d |  |  |  |  |  |  |
| 23 | 1.3 | képzés lebonyolítás |  | 20d | 2010-11-23 | 2010-12-21 | 22 |  |  | 0d |  | okt menedzser | 160h |  | 320,000 |  |
